# Target Hall shedule 132 Apr to Sep

Schedule from MS Project, 2017-03-21 to 2017-10-10, status date 2017-02-22, A marks actual dates.

## Calendars

- Standard: Mon-Fri 08:00-12:00, 13:00-17:00; Sat-Sun off.

## Resources

| Resource |
| --- |
| Wang.D |
| Cave.T |
| Fisher.C |
| Mjos.A |
| RPG |
| Target group |
| Mcdonald.D |
| Saboui. Y |
| Laxdal. A |
| Schmidt. A |

## Schedule

| ID | WBS | Task | Duration | Start | Finish | Predecessors | Complete | Constraint | Resources | Work | Actual work |
| --- | --- | --- | --- | --- | --- | --- | --- | --- | --- | --- | --- |
| 1 | 1 | **TM4 Lp UCx Ready for ITE** | 15.5d | 2017-03-21 08:00 A | 2017-04-11 12:00 A |  | 100% |  |  | 131.2h | 131.2h |
| 2 | 1.1 | Module Disconnection- TM2- ITE | 1d | 2017-03-21 08:00 A | 2017-03-21 17:00 A |  | 100% | start no earlier than 2017-03-21 08:00 | Wang.D; Saboui. Y | 16h | 16h |
| 3 | 1.2 | Module Move-TM4- Silo to TCS | 1d | 2017-03-22 08:00 A | 2017-03-22 17:00 A | 2 | 100% | start no earlier than 2017-03-22 08:00 | Cave.T; Wang.D; Saboui. Y | 24h | 24h |
| 4 | 1.3 | Module Move-TM2-ITE to SHC | 1d | 2017-03-23 08:00 A | 2017-03-23 17:00 A | 3 | 100% | finish no earlier than 2016-05-02 17:00 | Cave.T; Wang.D; Saboui. Y | 24h | 24h |
| 5 | 1.4 | Febiad Target Uninstallation | 0.5d | 2017-03-27 08:00 A | 2017-03-27 12:00 A | 4 | 100% | start no earlier than 2017-03-27 08:00 | Fisher.C | 4h | 4h |
| 6 | 1.5 | Moduel Move-TM2 SHC to Silo | 0.5d | 2017-03-27 13:00 A | 2017-03-27 17:00 A | 5 | 100% | start no earlier than 2016-05-09 08:00 | Cave.T; Wang.D; Saboui. Y | 12h | 12h |
| 7 | 1.6 | Lp UCx #19 Target Insert -SHC | 0.1d | 2017-03-28 08:00 A | 2017-03-28 08:48 A | 6 | 100% | start no earlier than 2017-03-28 08:00 | Fisher.C; Schmidt. A | 1.6h | 1.6h |
| 8 | 1.7 | Moudle Move-TM4-TCS to SHC | 0.25d | 2017-03-28 08:48 A | 2017-03-28 10:48 A | 7 | 100% | start no earlier than 2017-03-28 08:00 | Saboui. Y; Wang.D; Cave.T | 6h | 6h |
| 9 | 1.8 | UCx Target Installation/Electrical Check | 0.25d | 2017-03-28 10:48 A | 2017-03-28 13:48 A | 8 | 100% | start no earlier than 2017-03-28 08:00 | Cave.T; Fisher.C; Wang.D | 6h | 6h |
| 10 | 1.9 | Module Move TM4 - SHC to TCS/ Start of Pumps | 0.4d | 2017-03-28 13:48 A | 2017-03-28 17:00 A | 9 | 100% | start no earlier than 2017-03-28 08:00 | Saboui. Y; Cave.T; Wang.D | 9.6h | 9.6h |
| 11 | 1.10 | Module Connection-TM4-TSC | 0.5d | 2017-03-29 08:00 A | 2017-03-29 12:00 A | 10 | 100% | start no earlier than 2017-03-29 08:00 | Wang.D | 4h | 4h |
| 12 | 1.11 | Module Move -TM4-TCS to ITE | 0.5d | 2017-04-04 08:00 A | 2017-04-04 12:00 A |  | 100% | start no earlier than 2017-04-04 08:00 | Cave.T; Wang.D; Saboui. Y | 12h | 12h |
| 13 | 1.12 | Module Connection- TM4-ITE/ Start of Pumps | 0.5d | 2017-04-04 13:00 A | 2017-04-04 17:00 A | 12 | 100% | start no earlier than 2017-04-04 08:00 | Wang.D; Saboui. Y | 8h | 8h |
| 14 | 1.13 | Shielding Blocks Transfer-Storage to ITE | 0.5d | 2017-04-11 08:00 A | 2017-04-11 12:00 A | 13 | 100% | start no earlier than 2017-04-11 08:00 | Wang.D | 4h | 4h |
| 15 | 2 | **TM2 HP Ta Ready for ITW** | 20d | 2017-04-10 08:00 A | 2017-05-05 17:00 A |  | 100% |  |  | 54.4h | 54.4h |
| 16 | 2.1 | HP Ta#51 target Insert to SHC | 0.1d | 2017-04-10 08:00 A | 2017-04-10 08:48 A |  | 100% | start no earlier than 2017-04-10 08:00 | Fisher.C; Schmidt. A | 1.6h | 1.6h |
| 17 | 2.2 | Module Move-TM2-Silo to SHC | 0.2d | 2017-04-10 08:00 A | 2017-04-10 09:36 A |  | 100% | start no earlier than 2017-04-10 08:00 | Cave.T; Wang.D; Saboui. Y | 4.8h | 4.8h |
| 18 | 2.3 | Ta Installation/Electrical Check | 0.25d | 2017-04-10 09:36 A | 2017-04-10 11:36 A | 17 | 100% | start no earlier than 2016-06-07 08:00 | Cave.T; Fisher.C; Wang.D | 6h | 6h |
| 19 | 2.4 | Module Move-TM2-SHC to TCS | 0.25d | 2017-04-10 11:36 A | 2017-04-10 14:36 A | 18 | 100% | start no earlier than 2017-04-10 08:00 | Cave.T; Wang.D; Saboui. Y | 6h | 6h |
| 20 | 2.5 | Module Connection-TM2-TCS/Start of Pumps | 0.5d | 2017-04-11 08:00 A | 2017-04-11 12:00 A | 19 | 100% | start no earlier than 2017-04-11 08:00 | Wang.D; Cave.T; Saboui. Y | 12h | 12h |
| 21 | 2.6 | Module Disconnection-TM2 -TCS | 0.2d | 2017-04-25 08:00 A | 2017-04-25 09:36 A | 28 | 100% | start no earlier than 2017-04-25 08:00 | Wang.D | 1.6h | 1.6h |
| 22 | 2.7 | Module Move-TM2-TSC to ITW | 0.2d | 2017-04-25 09:36 A | 2017-04-25 11:12 A | 21 | 100% | start no earlier than 2016-06-14 08:00 | Cave.T; Wang.D; Saboui. Y | 4.8h | 4.8h |
| 23 | 2.8 | Module connection-TM2-ITW/Start of Pumps | 0.6d | 2017-04-25 11:12 A | 2017-04-25 17:00 A | 22 | 100% | start no earlier than 2016-06-14 08:00 | Wang.D; Saboui. Y | 9.6h | 9.6h |
| 24 | 2.9 | Shielding Blocks Transfer ITE to ITW | 1d | 2017-05-05 08:00 A | 2017-05-05 17:00 A | 23 | 100% | start no earlier than 2017-05-05 08:00 | Wang.D | 8h | 8h |

| ID | WBS | Task | Duration | Start | Finish | Predecessors | Complete | Remaining | Total slack | Free slack | Constraint | Resources | Work | Actual work |
| --- | --- | --- | --- | --- | --- | --- | --- | --- | --- | --- | --- | --- | --- | --- |
| 25 | 3 | **TM3 HV Investigation-SHC** | 9d | 2017-04-12 08:00 A | 2017-04-24 17:00 A |  | 100% |  |  |  |  |  | 148h | 148h |
| 26 | 3.1 | Module Move-TM3-Silo to SHC | 0.5d | 2017-04-12 08:00 A | 2017-04-12 12:00 A |  | 100% |  |  |  | start no earlier than 2017-04-12 08:00 | Saboui. Y; Cave.T; Wang.D | 12h | 12h |
| 27 | 3.2 | TM3 HV Investigation-SHC | 7d | 2017-04-13 08:00 A | 2017-04-21 17:00 A | 26 | 100% |  |  |  | finish no earlier than 2017-04-21 17:00 | Fisher.C; Laxdal. A | 112h | 112h |
| 28 | 3.3 | Module Move -TM3-SHC to Silo | 1d | 2017-04-24 08:00 A | 2017-04-24 17:00 A | 27 | 100% |  |  |  | start no earlier than 2017-04-24 08:00 | Cave.T; Saboui. Y; Wang.D | 24h | 24h |
| 29 | 4 | **TM4 LP UCx Ready for ITE** | 19d | 2017-05-09 08:00 A | 2017-06-02 17:00 A |  | 100% |  |  |  |  |  | 107.2h | 107.2h |
| 30 | 4.1 | Module Disconnection -TM4 -ITE | 1d | 2017-05-09 08:00 A | 2017-05-09 17:00 A | 24 | 100% |  |  |  | start no earlier than 2017-05-09 08:00 | Wang.D; Saboui. Y | 16h | 16h |
| 31 | 4.2 | Lp UCx #20 Target Insert into SHC | 0.2d | 2017-05-16 08:00 A | 2017-05-16 09:36 A | 30 | 100% |  |  |  | start no earlier than 2017-05-16 08:00 | Schmidt. A; Fisher.C | 3.2h | 3.2h |
| 32 | 4.3 | Module Move_TM4-ITE to SHC | 0.2d | 2017-05-16 09:36 A | 2017-05-16 11:12 A | 31 | 100% |  |  |  | start no earlier than 2017-05-16 08:00 | Cave.T; Wang.D; Saboui. Y | 4.8h | 4.8h |
| 33 | 4.4 | UCxTarget Installation/Electrical Check | 0.2d | 2017-05-16 11:12 A | 2017-05-16 13:48 A | 32 | 100% |  |  |  | start no earlier than 2017-05-03 08:00 | Cave.T; Fisher.C; Wang.D | 4.8h | 4.8h |
| 34 | 4.5 | Module Move-TM4-SHC to TCS | 0.2d | 2017-05-16 13:48 A | 2017-05-16 15:24 A | 33 | 100% |  |  |  | start no earlier than 2016-07-06 08:00 | Cave.T; Wang.D; Saboui. Y | 4.8h | 4.8h |
| 35 | 4.6 | Module Connection-TM4-TSC/Start of Pumps | 0.2d | 2017-05-16 15:24 A | 2017-05-16 17:00 A | 34 | 100% |  |  |  | start no earlier than 2016-07-06 08:00 | Wang.D | 1.6h | 1.6h |
| 36 | 4.7 | Target Inspection(PIE) | 1d | 2017-05-17 08:00 A | 2017-05-17 17:00 A |  | 100% |  |  |  | start no earlier than 2017-05-17 08:00 | Fisher.C; Mjos.A | 16h | 16h |
| 37 | 4.8 | Spent Target Move | 1d | 2017-05-18 08:00 A | 2017-05-18 17:00 A | 35 | 100% |  |  |  | start no earlier than 2017-05-18 08:00 | Cave.T; Fisher.C; Wang.D; Saboui. Y | 32h | 32h |
| 38 | 4.9 | Module Disconnetion-TM4-TCS | 0.2d | 2017-05-23 08:00 A | 2017-05-23 09:36 A | 37 | 100% |  |  |  | start no earlier than 2017-05-23 08:00 | Wang.D | 1.6h | 1.6h |
| 39 | 4.10 | Module Move-TM4-TCS to ITE | 0.2d | 2017-05-23 09:36 A | 2017-05-23 11:12 A | 38 | 100% |  |  |  | finish no earlier than 2016-07-12 17:00 | Cave.T; Wang.D; Saboui. Y | 4.8h | 4.8h |
| 40 | 4.11 | Module Connection-TM4-ITW/Start of Pumps | 0.6d | 2017-05-23 11:12 A | 2017-05-23 17:00 A | 39 | 100% |  |  |  | start no earlier than 2017-05-23 08:00 | Wang.D; Saboui. Y | 9.6h | 9.6h |
| 41 | 4.12 | Shielding Blocks Transfer-ITW to ITE | 1d | 2017-06-02 08:00 A | 2017-06-02 17:00 A | 40 | 100% |  |  |  | start no earlier than 2017-06-02 08:00 | Wang.D | 8h | 8h |
| 42 | 5 | **TM2 SiC Febiad Ready for ITW** | 11d | 2017-06-06 08:00 A | 2017-06-20 17:00 |  | 82% | 1.93d | 79.75d |  |  |  | 102.4h | 94.4h |
| 43 | 5.1 | SiC Febiad #36 Target Insert into SHC | 0.1d | 2017-06-06 08:00 A | 2017-06-06 08:48 A | 41 | 100% |  |  |  | start no earlier than 2017-06-06 08:00 | Fisher.C; Schmidt. A | 1.6h | 1.6h |
| 44 | 5.2 | Module Disconnection TM2-ITW | 0.2d | 2017-06-06 08:48 A | 2017-06-06 10:24 A | 43 | 100% |  |  |  | start no earlier than 2017-06-06 08:00 | Wang.D; Saboui. Y | 3.2h | 3.2h |
| 45 | 5.3 | Module Move-TM2-ITW to SHC | 0.2d | 2017-06-06 10:24 A | 2017-06-06 12:00 A | 44 | 100% |  |  |  | finish no earlier than 2016-08-02 17:00 | Cave.T; Wang.D; Saboui. Y | 4.8h | 4.8h |
| 46 | 5.4 | Target Installation/Electrical check-SHC | 0.2d | 2017-06-06 13:00 A | 2017-06-06 14:36 A | 45 | 100% |  |  |  | start no earlier than 2017-06-06 08:00 | Cave.T; Fisher.C; Wang.D | 4.8h | 4.8h |
| 47 | 5.5 | Module Move-TM2-SHC to TCS | 0.5d | 2017-06-07 08:00 A | 2017-06-07 12:00 A | 46 | 100% |  |  |  | start no earlier than 2017-06-07 08:00 | Cave.T; Wang.D; Saboui. Y | 12h | 12h |
| 48 | 5.6 | Module Connection-TM2-TCS/Start of Pumps | 0.5d | 2017-06-07 13:00 A | 2017-06-07 17:00 A | 47 | 100% |  |  |  | start no earlier than 2016-08-02 08:00 | Wang.D | 4h | 4h |
| 49 | 5.7 | Target Inspection(PIE) | 1d | 2017-06-08 08:00 A | 2017-06-08 17:00 A |  | 100% |  |  |  | start no earlier than 2017-06-08 08:00 | Fisher.C; Mjos.A | 16h | 16h |
| 50 | 5.8 | Spent Target Move | 1d | 2017-06-09 08:00 A | 2017-06-09 17:00 A | 48 | 100% |  |  |  | start no earlier than 2017-06-09 08:00 | Cave.T; Fisher.C; Wang.D; Saboui. Y | 32h | 32h |
| 51 | 5.9 | Module Disconnection-TM2-TSC | 0.25d | 2017-06-13 08:00 A | 2017-06-13 10:00 A | 50 | 100% |  |  |  | start no earlier than 2017-06-13 08:00 | Wang.D | 2h | 2h |
| 52 | 5.10 | Module Move-TM2-TCS to ITW | 0.25d | 2017-06-13 10:00 A | 2017-06-13 12:00 A | 51 | 100% |  |  |  | start no earlier than 2016-08-09 08:00 | Cave.T; Wang.D; Saboui. Y | 6h | 6h |
| 53 | 5.11 | Module Connection-TM2-ITW/Start of Pumps | 0.5d | 2017-06-13 13:00 A | 2017-06-13 17:00 A | 52 | 100% |  |  |  | start no earlier than 2017-06-13 08:00 | Wang.D; Saboui. Y | 8h | 8h |
| 54 | 5.12 | shielding Blocks Move - ITE to ITW | 1d | 2017-06-20 08:00 | 2017-06-20 17:00 | 53 |  |  | 79.75d | 4.75d | start no earlier than 2017-06-20 08:00 | Wang.D | 8h |  |

| ID | WBS | Task | Duration | Start | Finish | Predecessors | Total slack | Free slack | Constraint | Resources | Work |
| --- | --- | --- | --- | --- | --- | --- | --- | --- | --- | --- | --- |
| 55 | 6 | **TM4 LP Ta Ready for ITE** | 16d | 2017-06-27 08:00 | 2017-07-18 17:00 |  | 60d |  |  |  | 106h |
| 56 | 6.1 | LP Ta #52 Target Insert into SHC | 0.25d | 2017-06-27 15:00 | 2017-06-27 17:00 | 54 | 75d |  | finish no earlier than 2017-06-27 17:00 | Fisher.C; Schmidt. A | 4h |
| 57 | 6.2 | Module Disconnection-TM4-ITE | 0.25d | 2017-06-27 08:00 | 2017-06-27 10:00 |  | 73.25d | 0d | start no earlier than 2017-06-27 08:00 | Wang.D; Saboui. Y | 4h |
| 58 | 6.3 | Module Move-TM4-ITE to SHC | 0.25d | 2017-06-27 10:00 | 2017-06-27 12:00 | 57 | 73.25d | 0d | start no earlier than 2016-08-23 08:00 | Cave.T; Wang.D | 4h |
| 59 | 6.4 | New Target Installation/Electrical Check | 0.25d | 2017-06-27 13:00 | 2017-06-27 15:00 | 58 | 73.25d | 0.25d | start no earlier than 2016-08-24 08:00 | Cave.T; Fisher.C; Wang.D | 6h |
| 60 | 6.5 | Module Move-TM4-SHC to CS | 0.5d | 2017-06-28 08:00 | 2017-06-28 12:00 | 59 | 73d | 1.5d | start no earlier than 2017-06-28 08:00 | Wang.D; Cave.T; Saboui. Y | 12h |
| 61 | 6.6 | Module Connection-TM4-TCS/ Start of Pumps | 0.5d | 2017-06-28 08:00 | 2017-06-28 12:00 |  | 74.5d |  | start no earlier than 2017-06-28 08:00 | Wang.D; Saboui. Y | 8h |
| 62 | 6.7 | Target Inspection(PIE) | 1d | 2017-06-29 08:00 | 2017-06-29 17:00 |  | 73d |  | start no earlier than 2017-06-29 08:00 | Fisher.C; Mjos.A | 16h |
| 63 | 6.8 | Spent Target Move | 1d | 2017-06-30 08:00 | 2017-06-30 17:00 | 60 | 71.5d | 1d | start no earlier than 2017-06-30 08:00 | Cave.T; Wang.D; Fisher.C | 24h |
| 64 | 6.9 | Module Move-TM4-TCS to ITE | 0.5d | 2017-07-04 08:00 | 2017-07-04 12:00 | 63 | 70.5d |  | start no earlier than 2017-07-04 08:00 | Cave.T; Wang.D; Saboui. Y | 12h |
| 65 | 6.10 | Module Connection-TM4-ITE/Start of Pumps | 0.5d | 2017-07-04 13:00 | 2017-07-04 17:00 |  | 69d | 9d | finish no earlier than 2017-07-04 17:00 | Wang.D; Saboui. Y | 8h |
| 66 | 6.11 | Shielding Blocks Transfer-ITW to ITE | 1d | 2017-07-18 08:00 | 2017-07-18 17:00 | 65 | 60d |  | start no earlier than 2017-07-18 08:00 | Wang.D | 8h |
| 67 | 7 | **TM2 HP Ta Target Ready for ITW** | 16d | 2017-07-25 08:00 | 2017-08-15 17:00 |  | 40d |  |  |  | 108h |
| 68 | 7.1 | Module Disconnection TM2-ITW | 1d | 2017-07-25 08:00 | 2017-07-25 17:00 |  | 41.35d | 4d | start no earlier than 2017-07-25 08:00 | Wang.D; Saboui. Y | 16h |
| 69 | 7.2 | HP Ta #52 Target Insert into SHC | 0.25d | 2017-08-01 08:00 | 2017-08-01 10:00 |  | 50.75d |  | start no earlier than 2017-08-01 08:00 | Fisher.C; Schmidt. A | 4h |
| 70 | 7.3 | Module Move-TM2-ITW to SHC | 0.25d | 2017-08-01 08:00 | 2017-08-01 10:00 | 68 | 37.35d | 0d | start no earlier than 2017-08-01 08:00 | Cave.T; Wang.D; Saboui. Y | 6h |
| 71 | 7.4 | Target Installation/Electrical check-SHC | 0.25d | 2017-08-01 10:00 | 2017-08-01 12:00 | 70 | 37.35d | 0d | start no earlier than 2016-09-20 08:00 | Cave.T; Fisher.C; Wang.D | 6h |
| 72 | 7.5 | Module Move-TM2-SHC to TCS/Start of Pumps | 0.25d | 2017-08-01 13:00 | 2017-08-01 15:00 | 71 | 37.35d | 1.25d | start no earlier than 2017-08-01 08:00 | Cave.T; Wang.D | 4h |
| 73 | 7.6 | Target Inspection(PIE) | 1d | 2017-08-02 08:00 | 2017-08-02 17:00 |  | 49d |  | start no earlier than 2017-08-02 08:00 | Fisher.C; Mjos.A | 16h |
| 74 | 7.7 | Spent Target Move | 1d | 2017-08-03 08:00 | 2017-08-03 17:00 | 72 | 36.1d | 2d | start no earlier than 2017-08-03 08:00 | Cave.T; Fisher.C; Wang.D; Saboui. Y | 32h |
| 75 | 7.8 | Module Move-TM2-TCS to ITW | 0.5d | 2017-08-08 08:00 | 2017-08-08 12:00 | 74 | 34.1d | 0d | start no earlier than 2017-08-08 08:00 | Cave.T; Wang.D | 8h |
| 76 | 7.9 | Module Connection-TM2-ITW/Start of Pumps | 0.5d | 2017-08-08 13:00 | 2017-08-08 17:00 | 75 | 34.1d | 4d | start no earlier than 2016-09-27 08:00 | Wang.D; Saboui. Y | 8h |
| 77 | 7.10 | shielding Blocks Move - ITE to ITW | 1d | 2017-08-15 08:00 | 2017-08-15 17:00 | 76 | 30.1d | 4d | start no earlier than 2017-08-15 08:00 | Wang.D | 8h |
| 78 | 8 | **TM4 LP UCx Ready for ITE** | 15d | 2017-08-22 08:00 | 2017-09-11 17:00 |  | 21d |  |  |  | 112h |
| 79 | 8.1 | Module Disconnection TM4-ITE | 1d | 2017-08-22 08:00 | 2017-08-22 17:00 | 77 | 26.1d | 4d | start no earlier than 2017-08-22 08:00 | Wang.D; Saboui. Y | 16h |
| 80 | 8.2 | LP UCx #21 Target Insert into SHC | 0.1d | 2017-08-29 08:00 | 2017-08-29 08:48 |  | 30.9d |  | start no earlier than 2017-08-29 08:00 | Schmidt. A; Fisher.C | 1.6h |
| 81 | 8.3 | Module Move-TM4- ITE to SHC | 0.25d | 2017-08-29 08:00 | 2017-08-29 10:00 | 79 | 22.1d | 0d | start no earlier than 2017-08-29 08:00 | Cave.T; Saboui. Y; Wang.D | 6h |
| 82 | 8.4 | Target Installation/Electrical check-SHC | 0.25d | 2017-08-29 10:00 | 2017-08-29 12:00 | 81 | 22.1d | 0d | start no earlier than 2017-08-29 08:00 | Wang.D; Cave.T; Fisher.C | 6h |
| 83 | 8.5 | Module Move-TM4-SHC to TCS/Start of Pumps | 0.4d | 2017-08-29 13:00 | 2017-08-29 16:12 | 82 | 22.1d | 0.1d | start no earlier than 2017-08-29 08:00 | Wang.D; Saboui. Y | 6.4h |
| 84 | 8.6 | Target Inspection(PIE) | 1d | 2017-08-30 08:00 | 2017-08-30 17:00 | 83 | 22d | 0d | start no earlier than 2017-08-30 08:00 | Fisher.C; Mjos.A | 16h |
| 85 | 8.7 | Spent Target Move | 1d | 2017-08-31 08:00 | 2017-08-31 17:00 | 84 | 22d | 2d | start no earlier than 2017-08-31 08:00 | Fisher.C; Cave.T; Saboui. Y; Wang.D | 32h |
| 86 | 8.8 | Module Move-TM4-TCS to ITE | 0.5d | 2017-09-05 08:00 | 2017-09-05 12:00 | 85 | 20d | 0d | start no earlier than 2017-09-05 08:00 | Cave.T; Wang.D; Saboui. Y | 12h |
| 87 | 8.9 | Module Connection-TM4-ITE/Start of Pumps | 0.5d | 2017-09-05 13:00 | 2017-09-05 17:00 | 86 | 20d | 3d | start no earlier than 2017-09-05 08:00 | Saboui. Y; Wang.D | 8h |
| 88 | 8.10 | Shielding Blocks Transfer-ITW to ITE | 1d | 2017-09-11 08:00 | 2017-09-11 17:00 | 87 | 17d | 10d | start no earlier than 2017-09-11 08:00 | Wang.D | 8h |

| ID | WBS | Task | Duration | Start | Finish | Predecessors | Total slack | Free slack | Constraint | Resources | Work |
| --- | --- | --- | --- | --- | --- | --- | --- | --- | --- | --- | --- |
| 89 | 9 | **Beam Schedule 133 First Target Ready for ITW** | 11d | 2017-09-26 08:00 | 2017-10-10 17:00 |  | 0d |  |  |  | 104h |
| 90 | 9.1 | First Targt of 133 Schedule Insert into SHC | 0.25d | 2017-09-26 08:00 | 2017-09-26 10:00 |  | 10.75d |  | start no earlier than 2017-09-26 08:00 | Schmidt. A; Fisher.C | 4h |
| 91 | 9.2 | Module Move -TM2-ITW to SHC | 0.5d | 2017-09-26 08:00 | 2017-09-26 12:00 | 88 | 7d | 0d | start no earlier than 2017-09-26 08:00 | Cave.T; Saboui. Y; Wang.D | 12h |
| 92 | 9.3 | Target Installation/Electrical check-SHC | 0.5d | 2017-09-26 13:00 | 2017-09-26 17:00 | 91 | 7d | 0d | start no earlier than 2017-09-26 08:00 | Fisher.C; Cave.T | 8h |
| 93 | 9.4 | Module Move-TM2-SHC to TCS/Start of Pumps | 0.5d | 2017-09-27 08:00 | 2017-09-27 12:00 | 92 | 7d | 0d | start no earlier than 2017-09-27 08:00 | Cave.T; Wang.D; Saboui. Y | 12h |
| 94 | 9.5 | Target Inspection(PIE) | 0.5d | 2017-09-27 13:00 | 2017-09-27 17:00 | 93 | 7d | 0d | start no earlier than 2017-09-27 08:00 | Fisher.C; Mjos.A | 8h |
| 95 | 9.6 | Spent Target Move | 1d | 2017-09-28 08:00 | 2017-09-28 17:00 | 94 | 7d | 2d | start no earlier than 2017-09-28 08:00 | Cave.T; Fisher.C; Wang.D; Saboui. Y | 32h |
| 96 | 9.7 | Module Move-TM2-TCS to ITW | 0.5d | 2017-10-03 08:00 | 2017-10-03 12:00 | 95 | 5d | 0d | start no earlier than 2017-10-03 08:00 | Saboui. Y; Cave.T; Wang.D | 12h |
| 97 | 9.8 | Module Connection-TM2-ITW/Start of Pumps | 0.5d | 2017-10-03 13:00 | 2017-10-03 17:00 | 96 | 5d |  | start no earlier than 2017-10-03 08:00 | Wang.D; Saboui. Y | 8h |
| 98 | 9.9 | Shielding Blocks Move - ITE to ITW | 1d | 2017-10-10 08:00 | 2017-10-10 17:00 |  | 0d |  | start no earlier than 2017-10-10 08:00 | Wang.D | 8h |
